# U.P. Team - i

Schedule from MS Project, 2004-04-11 to 2004-06-30, A marks actual dates.
MMAA

## Calendars

- Standard: Mon-Sun 07:00-14:00. Exceptions (off unless hours are given): 2004-05-10 to 2004-05-16 07:00-14:00.

## Resources

| Resource |
| --- |
| Team 1 |
| 2 |
| 3 |
| 4 |
| 3&4 |
| U.P. Team |
| Team |
| t |
| All |
| God's Lnow |
| God's Know |
| ? |

## Schedule

| ID | WBS | Task | Type | Duration | Start | Finish | Complete | Remaining | Total slack | Free slack | Constraint | Deadline |
| --- | --- | --- | --- | --- | --- | --- | --- | --- | --- | --- | --- | --- |
| 1 | 1 | مشروع القانون | milestone | 0.75d? | 2004-05-06 A | 2004-05-06 A | 100% |  |  |  | start no earlier than 2004-05-06 |  |
| 3 | 2 | **اللوائح** |  | 70.88d? | 2004-04-11 A | 2004-06-30 | 80% | 14.16d? | 0d |  |  |  |
| 4 | 2.1 | لائحة العاملين |  | 45d | 2004-04-11 A | 2004-06-01 A | 100% |  |  |  | finish no earlier than 2004-05-31 |  |
| 5 | 2.2 | اللائحة المالية |  | 45d | 2004-04-11 A | 2004-06-01 A | 100% |  |  |  | finish no earlier than 2004-05-31 |  |
| 6 | 2.3 | لائحـة الهيكل التنظيمي واختصاصاته |  | 45.5d? | 2004-04-11 A | 2004-06-01 A | 100% |  |  |  |  |  |
| 7 | 2.4 | لائحة أعمال المشتريــات والمزايــــدات |  | 31.5d | 2004-04-27 A | 2004-06-01 A | 100% |  |  |  | finish no earlier than 2004-06-01 |  |
| 8 | 2.5 | اللوائح المتعلقة بتعارض المصالح |  | 31.5d | 2004-04-27 A | 2004-06-01 | 53% | 14.88d | 31.5d |  | finish no earlier than 2004-06-01 |  |
| 9 | 2.6 | اللوائح المتعلقة بالضوابط المهنية |  | 31.38d | 2004-04-27 A | 2004-06-01 | 53% | 14.81d | 31.5d |  | finish no earlier than 2004-06-01 |  |
| 10 | 2.7 | لائحة التدقيق والرقابة |  | 31.38d | 2004-04-27 A | 2004-06-01 | 53% | 14.81d | 31.5d |  | finish no earlier than 2004-06-01 |  |
| 11 | 2.8 | لائحة المناقصات |  | 31.38d | 2004-04-27 A | 2004-06-01 | 56% | 13.94d | 31.5d |  | finish no earlier than 2004-06-01 |  |
| 12 | 2.9 | اللائحة التنفيذية للائحة العاملين |  | 56.88d? | 2004-04-27 A | 2004-06-30 | 80% | 11.38d? | 0d |  | finish no earlier than 2004-06-30 |  |
| 14 | 3 | **الهيكل التنظيمي** |  | 25.38d? | 2004-05-01 A | 2004-05-29 | 71% | 7.42d? | 28d |  |  |  |
| 15 | 3.1 | **مكتب الرئيس** |  | 17.5d | 2004-05-01 A | 2004-05-20 | 30% | 12.25d | 15.88d |  |  |  |
| 16 | 3.1.1 | الشؤون القانونية |  | 8d | 2004-05-01 A | 2004-05-20 | 50% | 4d | 15.88d | 0d | finish no earlier than 2004-05-20 |  |
| 17 | 3.1.2 | العلاقات العامة - و مركز خدمة الجمهور |  | 8d | 2004-05-01 A | 2004-05-20 | 20% | 6.4d | 15.88d | 0d | finish no earlier than 2004-05-20 |  |
| 18 | 3.1.3 | التدقيق الداخلي |  | 8d | 2004-05-01 A | 2004-05-20 | 20% | 6.4d | 15.75d | 0d | finish no earlier than 2004-05-20 |  |
| 19 | 3.2 | **قطاع التخطيط** |  | 10.5d? | 2004-05-01 A | 2004-05-12 | 78% | 2.36d? | 42.88d |  |  |  |
| 20 | 3.2.1 | تنفيذ التخطيط |  | 10.5d | 2004-05-01 A | 2004-05-12 A | 100% |  |  |  | finish no earlier than 2004-05-20 |  |
| 21 | 3.2.2 | التخطيط العمراني |  | 10.5d | 2004-05-01 A | 2004-05-12 A | 100% |  |  |  | start no earlier than 2004-05-10 |  |
| 22 | 3.2.3 | التطوير العمراني |  | 10.5d | 2004-05-01 A | 2004-05-12 A | 100% |  |  |  | finish no earlier than 2004-05-20 |  |
| 23 | 3.2.4 | إدارة تنمية المشاريع |  | 10.5d? | 2004-05-01 A | 2004-05-12 | 10% | 9.45d? | 42.88d |  | finish no earlier than 2004-05-12 |  |
| 24 | 3.3 | **قطاع الأراضي** |  | 17.5d | 2004-05-01 A | 2004-05-20 | 80% | 3.5d | 18.38d |  |  | 2004-06-10 |
| 25 | 3.3.1 | أملاك الدولة |  | 15d | 2004-05-01 A | 2004-05-20 | 70% | 4.5d | 18.38d | 0d | finish no earlier than 2004-05-20 |  |
| 26 | 3.3.2 | الأراضي |  | 15d | 2004-05-01 A | 2004-05-20 | 70% | 4.5d | 18.38d | 0d | finish no earlier than 2004-05-20 |  |
| 27 | 3.3.3 | المساحة العامة |  | 15d | 2004-05-01 A | 2004-05-18 A | 100% |  |  |  | start no earlier than 2004-05-10 |  |

| ID | WBS | Task | Duration | Start | Finish | Predecessors | Complete | Remaining | Total slack | Free slack | Constraint |
| --- | --- | --- | --- | --- | --- | --- | --- | --- | --- | --- | --- |
| 28 | 3.4 | **قطاع الخدمات العامة** | 25.38d | 2004-05-01 A | 2004-05-29 |  | 76% | 6.09d | 18d |  |  |
| 29 | 3.4.1 | الشؤون الإدارية و المالية | 10d | 2004-05-01 A | 2004-05-12 A |  | 100% |  |  |  | finish no earlier than 2004-05-20 |
| 30 | 3.4.2 | الموارد البشرية | 10d | 2004-05-01 A | 2004-05-12 A |  | 100% |  |  |  | finish no earlier than 2004-05-20 |
| 31 | 3.4.3 | تقنية المعلومات | 10d | 2004-05-01 A | 2004-05-12 A |  | 100% |  |  |  | finish no earlier than 2004-05-20 |
| 32 | 3.4.4 | مركز نظم العلومات الجغرافية | 10d | 2004-05-01 A | 2004-05-12 A |  | 100% |  |  |  | start no earlier than 2004-05-10 |
| 33 | 3.4.5 | مركز التطوير المؤسسي | 12.62d | 2004-05-01 | 2004-05-29 |  |  |  | 8d | 0d | start no earlier than 2004-05-01 |
| 35 | 4 | **الهيكل الوظيفي** | 24.88d? | 2004-05-13 A | 2004-06-10 |  | 41% | 14.68d? | 18d |  |  |
| 36 | 4.1 | **مكتب الرئيس** | 10d | 2004-05-21 | 2004-06-01 |  |  |  | 15.75d |  |  |
| 37 | 4.1.1 | الشؤون القانونية | 10d | 2004-05-21 | 2004-06-01 | 16 |  |  | 15.88d | 0d | start no earlier than 2004-05-13 |
| 38 | 4.1.2 | العلاقات العامة - و مركز خدمة الجمهور | 10d | 2004-05-21 | 2004-06-01 | 17 |  |  | 15.88d | 0d | start no earlier than 2004-05-13 |
| 39 | 4.1.3 | التدقيق الداخلي | 10d | 2004-05-21 | 2004-06-01 | 18 |  |  | 19.75d | 0d | start no earlier than 2004-05-13 |
| 40 | 4.2 | **قطاع التخطيط** | 10.5d? | 2004-05-23 A | 2004-06-03 |  | 72% | 2.92d? | 23.62d |  |  |
| 41 | 4.2.1 | تنفيذ التخطيط | 10d | 2004-05-23 A | 2004-06-03 | 20 | 80% | 2d | 22.23d | 0d | finish no earlier than 2004-05-23 |
| 42 | 4.2.2 | التخطيط العمراني | 10d | 2004-05-23 A | 2004-06-03 | 21 | 80% | 2d | 22.12d | 0d | finish no earlier than 2004-05-23 |
| 43 | 4.2.3 | التطوير العمراني | 10d | 2004-05-23 A | 2004-06-03 | 22 | 80% | 2d | 22.12d | 0d | finish no earlier than 2004-05-23 |
| 44 | 4.2.4 | إدارة تنمية المشاريع | 10.5d? | 2004-05-23 A | 2004-06-03 |  | 50% | 5.25d? | 23.62d |  | finish no earlier than 2004-06-03 |
| 45 | 4.3 | **قطاع الأراضي** | 14d | 2004-05-13 A | 2004-05-28 |  | 65% | 4.87d | 28.88d |  |  |
| 46 | 4.3.1 | أملاك الدولة | 14d | 2004-05-13 A | 2004-05-28 | 25 | 65% | 4.87d | 23.88d | 0d | finish no earlier than 2004-05-27 |
| 47 | 4.3.2 | الأراضي | 14d | 2004-05-13 A | 2004-05-28 | 26 | 65% | 4.87d | 23.88d | 0d | finish no earlier than 2004-05-27 |
| 48 | 4.3.3 | المساحة العامة | 14d | 2004-05-13 A | 2004-05-28 | 27 | 65% | 4.87d | 28.88d |  | finish no earlier than 2004-05-27 |
| 49 | 4.4 | **قطاع الخدمات العامة** | 17d | 2004-05-22 A | 2004-06-10 |  | 20% | 13.6d | 18d |  |  |
| 50 | 4.4.1 | الشؤون الإدارية و المالية | 10d | 2004-05-22 | 2004-06-02 | 29 |  |  | 16d | 0d | start no earlier than 2004-05-22 |
| 51 | 4.4.2 | الموارد البشرية | 10d | 2004-05-22 | 2004-06-02 | 30 |  |  | 15d | 0d | start no earlier than 2004-05-22 |
| 52 | 4.4.3 | تقنية المعلومات | 10d | 2004-05-22 | 2004-06-02 | 31 |  |  | 15d | 0d | start no earlier than 2004-05-22 |
| 53 | 4.4.4 | مركز نظم العلومات الجغرافية | 10d | 2004-05-22 A | 2004-06-02 A | 32 | 100% |  |  |  | finish no earlier than 2004-05-23 |
| 54 | 4.4.5 | مركز التطوير المؤسسي | 10d | 2004-05-30 | 2004-06-10 | 33 |  |  | 8d | 0d | start no earlier than 2004-05-22 |

| ID | WBS | Task | Duration | Start | Finish | Predecessors | Complete | Remaining | Total slack | Constraint |
| --- | --- | --- | --- | --- | --- | --- | --- | --- | --- | --- |
| 56 | 5 | **الوصف الوظيفي** | 17.38d? | 2004-05-25 A | 2004-06-13 |  | 35% | 11.29d? | 15d |  |
| 57 | 5.1 | **مكتب الرئيس** | 10.12d? | 2004-06-01 | 2004-06-12 |  |  |  | 15.75d |  |
| 58 | 5.1.1 | الشؤون القانونية | 10d | 2004-06-01 | 2004-06-12 | 37 |  |  | 15.88d | start no earlier than 2004-05-25 |
| 59 | 5.1.2 | العلاقات العامة - و مركز خدمة الجمهور | 10d | 2004-06-01 | 2004-06-12 | 38 |  |  | 15.88d | start no earlier than 2004-05-25 |
| 60 | 5.1.3 | التدقيق الداخلي | 10.12d? | 2004-06-01 | 2004-06-12 | 39 |  |  | 15.75d | finish no earlier than 2004-06-12 |
| 61 | 5.2 | **قطاع التخطيط** | 10.5d? | 2004-05-25 A | 2004-06-05 |  | 60% | 4.2d? | 21.88d |  |
| 62 | 5.2.1 | تنفيذ التخطيط | 10.5d | 2004-05-25 A | 2004-06-05 | 41 | 82% | 1.9d | 21.88d | finish no earlier than 2004-06-05 |
| 63 | 5.2.2 | التخطيط العمراني | 10d | 2004-05-25 A | 2004-06-05 | 42 | 80% | 2d | 22.12d | finish no earlier than 2004-05-31 |
| 64 | 5.2.3 | التطوير العمراني | 10d | 2004-05-25 A | 2004-06-05 | 43 | 80% | 2d | 22.12d | finish no earlier than 2004-05-31 |
| 65 | 5.2.4 | إدارة تنمية المشاريع | 10.5d? | 2004-05-25 | 2004-06-05 |  |  |  | 21.88d | finish no earlier than 2004-06-05 |
| 66 | 5.3 | **قطاع الأراضي** | 10d | 2004-05-25 A | 2004-06-05 |  | 60% | 4d | 22.38d |  |
| 67 | 5.3.1 | أملاك الدولة | 10d | 2004-05-25 A | 2004-06-05 | 46 | 50% | 5d | 22.38d | finish no earlier than 2004-05-31 |
| 68 | 5.3.2 | الأراضي | 10d | 2004-05-25 A | 2004-06-05 | 47 | 50% | 5d | 22.38d | finish no earlier than 2004-05-31 |
| 69 | 5.3.3 | المساحة العامة | 10d | 2004-05-25 A | 2004-06-05 |  | 80% | 2d | 22.38d | finish no earlier than 2004-05-31 |
| 70 | 5.4 | **قطاع الخدمات العامة** | 10.38d | 2004-06-02 A | 2004-06-13 |  | 20% | 8.26d | 15d |  |
| 71 | 5.4.1 | الشؤون الإدارية و المالية | 9d | 2004-06-02 | 2004-06-12 | 50 |  |  | 16d | start no earlier than 2004-05-25 |
| 72 | 5.4.2 | الموارد البشرية | 10d | 2004-06-02 | 2004-06-13 | 51 |  |  | 15d | start no earlier than 2004-05-25 |
| 73 | 5.4.3 | تقنية المعلومات | 10d | 2004-06-02 | 2004-06-13 | 52 |  |  | 15d | start no earlier than 2004-05-25 |
| 74 | 5.4.4 | مركز نظم العلومات الجغرافية | 10d | 2004-06-02 A | 2004-06-13 A | 53 | 100% |  |  | finish no earlier than 2004-05-31 |
| 75 | 5.4.5 | مركز التطوير المؤسسي | 10d | 2004-06-02 | 2004-06-13 | 54 |  |  | 15.38d | start no earlier than 2004-06-02 |
